# OBRA DEFENSAS RIBEREÑAS RÍO LACRAMARCA

Schedule from Primavera P6, 2025-07-17 to 2025-10-14, data date 2025-07-17, costs in PEN.
Must finish by 2025-10-14

## Calendars

- Calendario Lacramarca: Mon-Sun 07:00-12:00, 14:00-19:00.

## Resources

| Resource | Group | Rate |
| --- | --- | --- |
| Costos | equipment | 1 |

## Schedule

| ID | WBS | Activity | Type | Duration | Start | Finish | Predecessors | Total float | Free float | Resources | Cost |
| --- | --- | --- | --- | --- | --- | --- | --- | --- | --- | --- | --- |
|  | 1 | **GESTION DE PROYECTO** |  |  | 2025-07-17 | 2025-10-14 |  |  |  |  |  |
|  | 1 | **HITOS** |  |  | 2025-07-17 | 2025-10-14 |  |  |  |  |  |
|  | 1 | **HITOS DEL PROYECTO** |  |  | 2025-07-17 | 2025-10-14 |  |  |  |  |  |
| HC_01 |  | HITO INICIO - CONTRACTUAL | milestone | 0d | 2025-07-17 | 2025-07-17 |  | -1d | 0d |  |  |
| HC_02 |  | HITO FIN - CONTRACTUAL | milestone | 0d | 2025-10-14 | 2025-10-14 | HC_01 FS+90d | -1d | 0d |  |  |
|  | 2 | **HITOS PLANIFICADOS** |  |  | 2025-07-17 | 2025-10-14 |  |  |  |  |  |
| HP_01 |  | HITO INICIO | milestone | 0d | 2025-07-17 | 2025-07-17 |  | -1d | 0d |  |  |
| HP_02 |  | HITO FIN | milestone | 0d | 2025-10-14 | 2025-10-14 | A1070 FF | -1d | 0d |  |  |
|  | 3 | **HITOS CLAVE DEL CONTRATO** |  |  | 2025-07-17 | 2025-10-14 |  |  |  |  |  |
| A1040 |  | Inicio plazo contractual dia 16 post KOM | milestone | 0d | 2025-07-17 | 2025-07-17 | HP_01 SS | -1d | 0d |  |  |
| A1050 |  | Inicio de excavaciones dia 21 | milestone | 0d | 2025-08-06 | 2025-08-06 | A1130 | 7d | 0d |  |  |
| A1060 |  | Inicio relleno de Dique Dia 26 | milestone | 0d | 2025-08-11 | 2025-08-11 | A1150 | 7d | 0d |  |  |
| A1070 |  | fin de plazo contractual dia 90 post KOM | milestone | 0d | 2025-10-14 | 2025-10-14 | A1110 FF | -1d | 0d |  |  |
|  | 3 | **EJECUCIÓN ACTUACIONES PENDIENTES DE SUBPROYECTO A1 - OPCION B** |  |  | 2025-07-17 | 2025-10-14 |  |  |  |  |  |
|  | 2 | **OBRAS PROVISIONALES** |  |  | 2025-07-17 | 2025-10-14 |  |  |  |  |  |
|  | 1 | **OBRAS PRELIMINARES** |  |  | 2025-07-17 | 2025-10-07 |  |  |  |  |  |
| A1080 |  | INSTALACIONES PROVISIONALES PARA LA OBRA |  | 5d | 2025-07-17 | 2025-07-21 | A1040 | -1d | 0d | Costos [82569.1 h] | 82,569.12 |
| A1090 |  | MANTENIMIENTO DE TRÁNSITO Y SEGURIDAD VIAL | level of effort | 78d | 2025-07-22 | 2025-10-07 | A1080 | 0d |  | Costos [49556.3 h] | 49,556.34 |
|  | 2 | **TRABAJOS PRELIMINARES** |  |  | 2025-07-17 | 2025-10-14 |  |  |  |  |  |
| A1100 |  | MOVILIZACIONDE EQUIPOS |  | 5d | 2025-07-17 | 2025-07-21 | A1080 SS | 7d | 0d | Costos [17700 h] | 17,700 |
| A1120 |  | TOPOGRAFÍA Y GEOREFERENCIACIÓN |  | 7d | 2025-07-22 | 2025-07-28 | A1100 | 7d | 0d | Costos [11888.7 h] | 11,888.67 |
| A1110 |  | DESMOVILIZACION DE EQUIPOS |  | 2d | 2025-10-13 | 2025-10-14 | A1820, A1770, A1570 | -1d | 0d | Costos [17700 h] | 17,700 |
|  | 3 | **DESCOLMATACIÓN DE CAUCE** |  |  | 2025-07-22 | 2025-08-10 |  |  |  |  |  |
| A1125 |  | DESBROCE Y LIMPIEZA EN ZONA NO BOSCOSA |  | 4d | 2025-07-22 | 2025-07-25 | A1080 | 26d | 0d | Costos [17880.4 h] | 17,880.4 |
| A1130 |  | DESCOLMATACIÓN DE CAUCE NATURAL DEL RÍO LACRAMARCA |  | 8d | 2025-07-29 | 2025-08-05 | A1120 | 7d | 0d | Costos [7360.26 h] | 7,360.26 |
| A1140 |  | CONFORMACIÓN DE DESVIO EN CAUCE DE RÍO |  | 5d | 2025-08-06 | 2025-08-10 | A1120, A1130 | 7d | 0d | Costos [21267.3 h] | 21,267.3 |

| ID | WBS | Activity | Duration | Start | Finish | Predecessors | Total float | Free float | Resources | Cost |
| --- | --- | --- | --- | --- | --- | --- | --- | --- | --- | --- |
|  | 4 | **DIQUES DE TIERRA COMPACTADA CON ENROCADO** |  | 2025-07-26 | 2025-10-11 |  |  |  |  |  |
|  | 1 | **DIQUE DE TIERRA COMPACTADA A1-D-01** |  | 2025-08-06 | 2025-08-20 |  |  |  |  |  |
| A1150 |  | EXCAVACIÓN EN TERRENO NATURAL CON EQUIPO | 5d | 2025-08-06 | 2025-08-10 | A1130, A1050 SS | 7d | 0d | Costos [271526 h] | 271,526.08 |
| A1160 |  | EXCAVACIÓN DE UÑA CON EQUIPO | 4d | 2025-08-11 | 2025-08-14 | A1150 | 7d | 0d | Costos [19690.4 h] | 19,690.42 |
| A1180 |  | Pedraplén e=60 cm | 2d | 2025-08-11 | 2025-08-12 | A1160 SS | 9d | 2d | Costos [62900.9 h] | 62,900.95 |
| A1200 |  | CONFORMACIÓN DE CUERPO DE DIQUE CON MATERIAL DE PRÉSTAMO | 4d | 2025-08-11 | 2025-08-14 | A1140, A1190 FF, A1060 SS | 7d | 0d | Costos [99969.3 h] | 99,969.29 |
| A1240 |  | CONFORMACIÓN DE RELLENO NO ESTRUCTURAL CON MATERIAL PROPIO | 4d | 2025-08-11 | 2025-08-14 | A1200 SS | 13d | 6d | Costos [45738.5 h] | 45,738.54 |
| A1170 |  | PERFILADO Y COMPACTACIÓN EN ZONA DE CORTE | 2d | 2025-08-13 | 2025-08-14 | A1150, A1160 FF | 7d | 0d | Costos [65872.1 h] | 65,872.11 |
| A1190 |  | Pedraplén e=30 cm | 2d | 2025-08-13 | 2025-08-14 | A1180 SS, A1170 FF | 7d | 0d | Costos [39084.7 h] | 39,084.72 |
| A1215 |  | GEOTEXTIL NO TEJIDO 400 G/M2, INC. COLOCACIÓN | 2d | 2025-08-15 | 2025-08-16 | A1200 | 7d | 0d | Costos [272398 h] | 272,397.87 |
| A1210 |  | CONFORMACIÓN DE MATERIAL GRANULAR EN CORONA DE DIQUE | 4d | 2025-08-17 | 2025-08-20 | A1215 | 7d | 0d | Costos [7478.13 h] | 7,478.13 |
| A1220 |  | COLOCACION Y ACOMODO DE ROCA EN UÑA DE DIQUE | 4d | 2025-08-17 | 2025-08-20 | A1215 | 7d | 0d | Costos [41961.4 h] | 41,961.41 |
| A1230 |  | COLOCACION Y ACOMODO DE ROCA EN TALUD DE DIQUE | 4d | 2025-08-17 | 2025-08-20 | A1215, A1240 FF | 7d | 0d | Costos [36724.8 h] | 36,724.78 |
|  | 2 | **DIQUE DE TIERRA COMPACTADA A1-I-01** |  | 2025-08-21 | 2025-09-05 |  |  |  |  |  |
| A1250 |  | EXCAVACIÓN EN TERRENO NATURAL CON EQUIPO | 4d | 2025-08-21 | 2025-08-24 | A1210, A1220, A1230 | 7d | 0d | Costos [43569.7 h] | 43,569.69 |
| A1260 |  | EXCAVACIÓN DE UÑA CON EQUIPO | 4d | 2025-08-25 | 2025-08-28 | A1250 | 7d | 0d | Costos [3813.22 h] | 3,813.22 |
| A1270 |  | PERFILADO Y COMPACTACIÓN EN ZONA DE CORTE | 4d | 2025-08-25 | 2025-08-28 | A1260 SS | 46d | 0d | Costos [13004.6 h] | 13,004.58 |
| A1280 |  | Pedraplén e=60 cm | 2d | 2025-08-25 | 2025-08-26 | A1260 SS | 7d | 0d | Costos [12382.9 h] | 12,382.93 |
| A1290 |  | Pedraplén e=30 cm | 2d | 2025-08-27 | 2025-08-28 | A1280, A1270 FF, A1260 FF | 46d | 47d | Costos [7705.57 h] | 7,705.57 |
| A1300 |  | CONFORMACIÓN DE CUERPO DE DIQUE CON MATERIAL DE PRÉSTAMO | 4d | 2025-08-27 | 2025-08-30 | A1280 | 7d | 0d | Costos [20794.4 h] | 20,794.43 |
| A1320 |  | GEOTEXTIL NO TEJIDO 400 G/M2, INC. COLOCACIÓN | 2d | 2025-08-31 | 2025-09-01 | A1300 | 7d | 0d | Costos [53814.6 h] | 53,814.58 |
| A1350 |  | CONFORMACIÓN DE RELLENO NO ESTRUCTURAL CON MATERIAL PROPIO | 4d | 2025-08-31 | 2025-09-03 | A1300 | 9d | 2d | Costos [11013.9 h] | 11,013.93 |
| A1310 |  | CONFORMACIÓN DE MATERIAL GRANULAR EN CORONA DE DIQUE | 3d | 2025-09-02 | 2025-09-04 | A1320 | 8d | 9d | Costos [1447.38 h] | 1,447.38 |
| A1330 |  | COLOCACION Y ACOMODO DE ROCA EN UÑA DE DIQUE | 4d | 2025-09-02 | 2025-09-05 | A1320 | 7d | 0d | Costos [8121.56 h] | 8,121.56 |
| A1340 |  | COLOCACION Y ACOMODO DE ROCA EN TALUD DE DIQUE | 4d | 2025-09-02 | 2025-09-05 | A1330 SS, A1350 FF | 7d | 8d | Costos [7383.24 h] | 7,383.24 |

| ID | WBS | Activity | Duration | Start | Finish | Predecessors | Total float | Free float | Resources | Cost |
| --- | --- | --- | --- | --- | --- | --- | --- | --- | --- | --- |
|  | 3 | **DIQUE DE TIERRA COMPACTADA A1-D-02** |  | 2025-09-14 | 2025-09-28 |  |  |  |  |  |
| A1360 |  | EXCAVACIÓN EN TERRENO NATURAL CON EQUIPO | 4d | 2025-09-14 | 2025-09-17 | A1310, A1330, A1340, A1980 | -1d | 0d | Costos [45432.5 h] | 45,432.52 |
| A1370 |  | EXCAVACIÓN DE UÑA CON EQUIPO | 4d | 2025-09-18 | 2025-09-21 | A1360 | 22d | 0d | Costos [3788.67 h] | 3,788.67 |
| A1380 |  | PERFILADO Y COMPACTACIÓN EN ZONA DE CORTE | 4d | 2025-09-18 | 2025-09-21 | A1370 SS | 22d | 0d | Costos [16482.9 h] | 16,482.91 |
| A1390 |  | Pedraplén e=60 cm | 2d | 2025-09-18 | 2025-09-19 | A1360 | -1d | 0d | Costos [14083.3 h] | 14,083.3 |
| A1400 |  | Pedraplén e=30 cm | 2d | 2025-09-20 | 2025-09-21 | A1390, A1370 FF, A1380 FF | 22d | 23d | Costos [8713.42 h] | 8,713.42 |
| A1410 |  | CONFORMACIÓN DE CUERPO DE DIQUE CON MATERIAL DE PRÉSTAMO | 3d | 2025-09-20 | 2025-09-22 | A1390 | -1d | 0d | Costos [39509.1 h] | 39,509.1 |
| A1430 |  | GEOTEXTIL NO TEJIDO 400 G/M2, INC. COLOCACIÓN | 2d | 2025-09-23 | 2025-09-24 | A1410 | -1d | 0d | Costos [61775.6 h] | 61,775.57 |
| A1460 |  | CONFORMACIÓN DE RELLENO NO ESTRUCTURAL CON MATERIAL PROPIO | 4d | 2025-09-24 | 2025-09-27 | A1410, A1420 FF, A1440 FF | -1d | 0d | Costos [26617.5 h] | 26,617.48 |
| A1420 |  | CONFORMACIÓN DE MATERIAL GRANULAR EN CORONA DE DIQUE | 3d | 2025-09-25 | 2025-09-27 | A1430 | -1d | 0d | Costos [1160.36 h] | 1,160.36 |
| A1440 |  | COLOCACION Y ACOMODO DE ROCA EN UÑA DE DIQUE | 3d | 2025-09-25 | 2025-09-27 | A1430 | -1d | 0d | Costos [8258.97 h] | 8,258.97 |
| A1450 |  | COLOCACION Y ACOMODO DE ROCA EN TALUD DE DIQUE | 4d | 2025-09-25 | 2025-09-28 | A1430 | 1d | 2d | Costos [10195.7 h] | 10,195.71 |
|  | 4 | **DIQUE DE TIERRA COMPACTADA A1-I-02** |  | 2025-09-28 | 2025-10-11 |  |  |  |  |  |
| A1470 |  | EXCAVACIÓN EN TERRENO NATURAL CON EQUIPO | 3d | 2025-09-28 | 2025-09-30 | A1460, A1450 FF | -1d | 0d | Costos [64638.3 h] | 64,638.26 |
| A1480 |  | EXCAVACIÓN DE UÑA CON EQUIPO | 3d | 2025-10-01 | 2025-10-03 | A1470 | 10d | 11d | Costos [4156.35 h] | 4,156.35 |
| A1490 |  | PERFILADO Y COMPACTACIÓN EN ZONA DE CORTE | 4d | 2025-10-01 | 2025-10-04 | A1470 | 6d | 3d | Costos [16795.4 h] | 16,795.42 |
| A1500 |  | Pedraplén e=60 cm | 2d | 2025-10-01 | 2025-10-02 | A1470 | -1d | 0d | Costos [24774.1 h] | 24,774.14 |
| A1510 |  | Pedraplén e=30 cm | 2d | 2025-10-03 | 2025-10-04 | A1500 | 6d | 3d | Costos [9511.57 h] | 9,511.57 |
| A1520 |  | CONFORMACIÓN DE CUERPO DE DIQUE CON MATERIAL DE PRÉSTAMO | 3d | 2025-10-03 | 2025-10-05 | A1500 | -1d | 0d | Costos [41295 h] | 41,295.04 |
| A1540 |  | GEOTEXTIL NO TEJIDO 400 G/M2, INC. COLOCACIÓN | 2d | 2025-10-06 | 2025-10-07 | A1520 | -1d | 0d | Costos [68016.3 h] | 68,016.28 |
| A1530 |  | CONFORMACIÓN DE MATERIAL GRANULAR EN CORONA DE DIQUE | 3d | 2025-10-08 | 2025-10-10 | A1540, A1490, A1510 | 3d | 1d | Costos [1045.26 h] | 1,045.26 |
| A1550 |  | COLOCACION Y ACOMODO DE ROCA EN UÑA DE DIQUE | 4d | 2025-10-08 | 2025-10-11 | A1540, A1530 FF | 2d | 3d | Costos [8852.37 h] | 8,852.37 |
| A1560 |  | COLOCACION Y ACOMODO DE ROCA EN TALUD DE DIQUE | 3d | 2025-10-08 | 2025-10-10 | A1540 | -1d | 0d | Costos [10394 h] | 10,393.96 |
| A1570 |  | CONFORMACIÓN DE RELLENO NO ESTRUCTURAL CON MATERIAL PROPIO | 4d | 2025-10-08 | 2025-10-11 | A1540, A1090 | 0d | 1d | Costos [32338.4 h] | 32,338.42 |

| ID | WBS | Activity | Duration | Start | Finish | Predecessors | Total float | Free float | Resources | Cost |
| --- | --- | --- | --- | --- | --- | --- | --- | --- | --- | --- |
|  | 5 | **RAMPAS** |  | 2025-07-26 | 2025-08-09 |  |  |  |  |  |
| A1580 |  | EXCAVACIÓN EN TERRENO NATURAL CON EQUIPO | 7d | 2025-07-26 | 2025-08-01 | A1125 | 26d | 0d | Costos [89.8 h] | 89.8 |
| A1590 |  | CONFORMACIÓN DE CUERPO DE RAMPA CON MATERIAL DE PRESTAMO | 4d | 2025-08-02 | 2025-08-05 | A1580 | 30d | 0d | Costos [658.25 h] | 658.25 |
| A1595 |  | CONFORMACIÓN DE CORONA DE RAMPA CON MATERIAL DE PRESTAMO | 4d | 2025-08-06 | 2025-08-09 | A1590 | 30d | 0d | Costos [2350.41 h] | 2,350.41 |
|  | 6 | **OBRAS DE ARTE (REBOSES)** |  | 2025-08-10 | 2025-09-17 |  |  |  |  |  |
|  | 1 | **ESTRUCTURA DE REBOSE** |  | 2025-08-10 | 2025-09-17 |  |  |  |  |  |
|  | 1 | **MOVIMIENTO DE TIERRAS** |  | 2025-08-10 | 2025-08-20 |  |  |  |  |  |
| A1600 |  | DESBROCE Y LIMPIEZA | 2d | 2025-08-10 | 2025-08-11 | A1595 | 41d | 0d | Costos [836.78 h] | 836.78 |
| A1610 |  | EXCAVACION ESTRUCTURAL BAJO AGUA (EXCAVACION ESTRUCTURAL PARA OBRAS DE ARTE) | 5d | 2025-08-12 | 2025-08-16 | A1600 | 41d | 0d | Costos [6746.88 h] | 6,746.88 |
| A1620 |  | CAMA DE ARENA | 4d | 2025-08-13 | 2025-08-16 | A1610 FF, A1600 | 41d | 0d | Costos [1314.95 h] | 1,314.95 |
| A1630 |  | RELLENO ESTRUCTURAL PARA OBRAS DE ARTE CON MATERIAL DE PRÉSTAMO | 4d | 2025-08-17 | 2025-08-20 | A1620 | 41d | 0d | Costos [2021.91 h] | 2,021.91 |
|  | 2 | **OBRAS DE CONCRETO** |  | 2025-08-16 | 2025-09-17 |  |  |  |  |  |
| A1640 |  | CONCRETO F'C=100 Kg/cm2 | 5d | 2025-08-16 | 2025-08-20 | A1630 FF, A1620 SS | 41d | 0d | Costos [2313.2 h] | 2,313.2 |
| A1650 |  | CONCRETO F'C=280 Kg/cm2 | 5d | 2025-08-21 | 2025-08-25 | A1640 | 41d | 0d | Costos [24440.9 h] | 24,440.93 |
| A1660 |  | ENCOFRADO Y DESENCOFRADO RECTO | 4d | 2025-08-26 | 2025-08-29 | A1650 | 41d | 3d | Costos [25471.7 h] | 25,471.65 |
| A1670 |  | ACERO DE REFUERZO Fy=4200 Kg/cm2 | 3d | 2025-09-15 | 2025-09-17 | A1660, A1690 FF | 26d | 27d | Costos [21130.2 h] | 21,130.25 |
|  | 3 | **TUBERIAS** |  | 2025-08-29 | 2025-09-17 |  |  |  |  |  |
| A1680 |  | SUMINISTRO DE TUBERÍA HDPE DN800 mm | 4d | 2025-08-29 | 2025-09-01 | A1600, A1660 FF, A1710 | 38d | 12d | Costos [4405.03 h] | 4,405.03 |
| A1690 |  | INSTALACIÓN DE TUBERÍA HDPE DN800 mm | 4d | 2025-09-14 | 2025-09-17 | A1680, A1710 FF, A1750 FF | 26d | 0d | Costos [4405.03 h] | 4,405.03 |
|  | 3 | **TRANSPORTE DE MATERIAL** |  | 2025-08-02 | 2025-09-17 |  |  |  |  |  |
| A1720 |  | TRANSPORTE DE ROCA PARA DISTANCIAS <1KM | 12d | 2025-08-02 | 2025-08-13 | A1580 | 26d | 0d | Costos [19283.2 h] | 19,283.25 |
| A1730 |  | TRANSPORTE DE ROCA PARA DISTANCIAS >1KM | 12d | 2025-08-02 | 2025-08-13 | A1720 SS | 41d | 15d | Costos [134622 h] | 134,621.82 |
| A1700 |  | TRANSPORTE DE MATERIAL GRANULAR PARA DISTANCIAS <1KM | 15d | 2025-08-14 | 2025-08-28 | A1595, A1720 | 26d | 0d | Costos [55508.3 h] | 55,508.33 |
| A1710 |  | TRANSPORTE DE MATERIAL GRANULAR PARA DISTANCIAS >1KM | 15d | 2025-08-14 | 2025-08-28 | A1700 SS | 26d | 0d | Costos [456466 h] | 456,465.81 |
| A1740 |  | TRANSPORTE DE MATERIAL EXCEDENTE PARA DISTANCIAS <1KM | 20d | 2025-08-29 | 2025-09-17 | A1595, A1730, A1710 | 26d | 0d | Costos [252782 h] | 252,781.94 |
| A1750 |  | TRANSPORTE DE MATERIAL EXCEDENTE PARA DISTANCIAS >1KM | 20d | 2025-08-29 | 2025-09-17 | A1740 SS | 26d | 0d | Costos [943015 h] | 943,014.64 |

| ID | WBS | Activity | Type | Duration | Start | Finish | Predecessors | Total float | Free float | Resources | Cost |
| --- | --- | --- | --- | --- | --- | --- | --- | --- | --- | --- | --- |
|  | 1 | **IMPACTO AMBIENTAL** |  |  | 2025-07-22 | 2025-10-12 |  |  |  |  |  |
|  | 1 | **TRABAJOS DE CIERRE** |  |  | 2025-07-22 | 2025-10-12 |  |  |  |  |  |
| A1760 |  | ACONDICIONAMIENTO DE DEPOSITOS DE MATERIALES EXCEDENTES (DME) |  | 4d | 2025-07-22 | 2025-07-25 | A1080 | 45d | 46d | Costos [167595 h] | 167,594.94 |
| A1770 |  | SEGURIDAD Y SALUD OCUPACIONAL | level of effort | 83d | 2025-07-22 | 2025-10-12 | A1100 | -1d | 0d | Costos [41380.6 h] | 41,380.63 |
|  | 4 | **EJECUCIÓN ACTUACIONES PENDIENTES DE SUBPROYECTO A2-1 - OPCION B** |  |  | 2025-07-22 | 2025-10-12 |  |  |  |  |  |
|  | 2 | **OBRAS PROVISIONALES** |  |  | 2025-07-22 | 2025-10-12 |  |  |  |  |  |
|  | 1 | **OBRAS PRELIMINARES** |  |  | 2025-07-22 | 2025-07-29 |  |  |  |  |  |
| A1790 |  | INSTALACIONES PROVISIONALES PARA LA OBRA |  | 4d | 2025-07-22 | 2025-07-25 | A1080 | -1d | 0d | Costos [82569.1 h] | 82,569.12 |
| A1800 |  | MANTENIMIENTO DE TRÁNSITO Y SEGURIDAD VIAL |  | 4d | 2025-07-26 | 2025-07-29 | A1790 | 41d | 42d | Costos [49556.3 h] | 49,556.34 |
|  | 2 | **TRABAJOS PRELIMINARES** |  |  | 2025-07-22 | 2025-10-12 |  |  |  |  |  |
| A1810 |  | MOVILIZACION DE EQUIPOS |  | 4d | 2025-07-22 | 2025-07-25 | A1790 SS | -1d | 0d | Costos [17900 h] | 17,900 |
| A1830 |  | TOPOGRAFÍA Y GEOREFERENCIACIÓN |  | 4d | 2025-07-26 | 2025-07-29 | A1810 | -1d | 0d | Costos [11888.7 h] | 11,888.67 |
| A1820 |  | DESMOVILIZACION DE EQUIPOS |  | 2d | 2025-10-11 | 2025-10-12 | A1560, A2160 | -1d | 0d | Costos [17900 h] | 17,900 |
|  | 3 | **DESCOLMATACIÓN DE CAUCE** |  |  | 2025-07-30 | 2025-08-10 |  |  |  |  |  |
| A1840 |  | DESBROCE Y LIMPIEZA EN ZONA NO BOSCOSA |  | 4d | 2025-07-30 | 2025-08-02 | A1830 | -1d | 0d | Costos [9091.69 h] | 9,091.69 |
| A1850 |  | DESCOLMATACIÓN DE CAUCE NATURAL DEL RÍO LACRAMARCA |  | 4d | 2025-08-03 | 2025-08-06 | A1840 | 3d | 4d | Costos [4841.17 h] | 4,841.17 |
| A1860 |  | CONFORMACIÓN DE DESVIO EN CAUCE DE RÍO |  | 4d | 2025-08-03 | 2025-08-06 | A1840 | -1d | 0d | Costos [8397.24 h] | 8,397.24 |
| A1870 |  | RELLENO NO ESTRUCTURAL CON MATERIAL PROPIO |  | 4d | 2025-08-07 | 2025-08-10 | A1860, A1850 FF | -1d | 0d | Costos [25679.7 h] | 25,679.65 |
|  | 4 | **DIQUES DE TIERRA COMPACTADA CON ENROCADO** |  |  | 2025-08-11 | 2025-09-13 |  |  |  |  |  |
|  | 1 | **DIQUE DE TIERRA COMPACTADA A2-D-01** |  |  | 2025-08-11 | 2025-09-13 |  |  |  |  |  |
| A1880 |  | EXCAVACIÓN EN TERRENO NATURAL CON EQUIPO |  | 5d | 2025-08-11 | 2025-08-15 | A1870 | -1d | 0d | Costos [94142.9 h] | 94,142.87 |
| A1890 |  | EXCAVACIÓN DE UÑA CON EQUIPO |  | 5d | 2025-08-16 | 2025-08-20 | A1880 | -1d | 0d | Costos [8315.12 h] | 8,315.12 |
| A1900 |  | PERFILADO EN ZONA DE CORTE EN FUNDACIÓN Y TALUD |  | 4d | 2025-08-16 | 2025-08-19 | A1880 | 55d | 56d | Costos [11734.7 h] | 11,734.67 |
| A1910 |  | Pedraplén e=60 cm |  | 2d | 2025-08-16 | 2025-08-17 | A1880 | 2d | 0d | Costos [85849.6 h] | 85,849.57 |
| A1920 |  | Pedraplén e=30 cm |  | 2d | 2025-08-18 | 2025-08-19 | A1910 | 17d | 12d | Costos [15014.8 h] | 15,014.83 |
| A1930 |  | CONFORMACIÓN DE CUERPO DE DIQUE CON MATERIAL PROPIO |  | 5d | 2025-08-18 | 2025-08-22 | A1910 | 5d | 0d | Costos [37448.7 h] | 37,448.65 |
| A1950 |  | CONFORMACIÓN DE MATERIAL GRANULAR EN CORONA DE DIQUE |  | 4d | 2025-08-23 | 2025-08-26 | A1930 | 5d | 0d | Costos [1945.17 h] | 1,945.17 |
| A1940 |  | CONFORMACIÓN DE RELLENO NO ESTRUCTURAL CON MATERIAL PROPIO |  | 5d | 2025-08-27 | 2025-08-31 | A1950, A1920 FF | 5d | 0d | Costos [19521.9 h] | 19,521.92 |
| A1960 |  | GEOTEXTIL NO TEJIDO 400 G/M2, INC. COLOCACIÓN |  | 4d | 2025-09-01 | 2025-09-04 | A1940 | 5d | 0d | Costos [18039.5 h] | 18,039.48 |
| A1970 |  | COLOCACION Y ACOMODO DE ROCA EN UÑA DE DIQUE |  | 3d | 2025-09-05 | 2025-09-07 | A1960 | 36d | 37d | Costos [16926.8 h] | 16,926.76 |
| A1980 |  | COLOCACION Y ACOMODO DE ROCA EN TALUD DE DIQUE |  | 3d | 2025-09-11 | 2025-09-13 | A1960, A2080 FF, A2150 | -1d | 0d | Costos [13593.1 h] | 13,593.14 |

| ID | WBS | Activity | Type | Duration | Start | Finish | Predecessors | Total float | Free float | Resources | Cost |
| --- | --- | --- | --- | --- | --- | --- | --- | --- | --- | --- | --- |
|  | 2 | **DIQUE DE TIERRA COMPACTADA A2-I-01** |  |  | 2025-08-18 | 2025-09-13 |  |  |  |  |  |
| A1990 |  | EXCAVACIÓN EN TERRENO NATURAL CON EQUIPO |  | 3d | 2025-08-18 | 2025-08-20 | A1910 | 2d | 0d | Costos [79887.6 h] | 79,887.62 |
| A2000 |  | EXCAVACIÓN DE UÑA CON EQUIPO |  | 3d | 2025-08-21 | 2025-08-23 | A1990 | 2d | 0d | Costos [9233.98 h] | 9,233.98 |
| A2010 |  | PERFILADO EN ZONA DE CORTE EN FUNDACIÓN Y TALUD |  | 4d | 2025-08-24 | 2025-08-27 | A1990, A2000 | 2d | 0d | Costos [15670.2 h] | 15,670.2 |
| A2020 |  | Pedraplén e=60 cm |  | 2d | 2025-08-28 | 2025-08-29 | A1990, A2010 | 2d | 0d | Costos [89041 h] | 89,041.03 |
| A2030 |  | Pedraplén e=30 cm |  | 2d | 2025-08-30 | 2025-08-31 | A2020 | 8d | 0d | Costos [15679.5 h] | 15,679.54 |
| A2050 |  | CONFORMACIÓN DE RELLENO NO ESTRUCTURAL CON MATERIAL PROPIO |  | 4d | 2025-08-30 | 2025-09-02 | A2020 | 2d | 0d | Costos [23512.4 h] | 23,512.37 |
| A2070 |  | COLOCACION Y ACOMODO DE ROCA EN UÑA DE DIQUE |  | 4d | 2025-09-01 | 2025-09-04 | A2030 | 8d | 6d | Costos [18789.7 h] | 18,789.66 |
| A2040 |  | CONFORMACIÓN DE CUERPO DE DIQUE CON MATERIAL PROPIO |  | 4d | 2025-09-03 | 2025-09-06 | A2050 | 2d | 0d | Costos [37642 h] | 37,642 |
| A2055 |  | CONFORMACIÓN DE MATERIAL GRANULAR EN CORONA DE DIQUE |  | 4d | 2025-09-07 | 2025-09-10 | A2040 | 2d | 0d | Costos [2990.64 h] | 2,990.64 |
| A2060 |  | GEOTEXTIL NO TEJIDO 400 G/M2, INC. COLOCACIÓN |  | 3d | 2025-09-08 | 2025-09-10 | A2040, A2055 FF, A2070 FF | 2d | 3d | Costos [20676.4 h] | 20,676.42 |
| A2080 |  | COLOCACION Y ACOMODO DE ROCA EN TALUD DE DIQUE |  | 4d | 2025-09-10 | 2025-09-13 | A2060 FF, A2100, A2140 FF, A1800, A1760 | -1d | 0d | Costos [15309.4 h] | 15,309.42 |
|  | 3 | **TRANSPORTE DE MATERIAL** |  |  | 2025-08-21 | 2025-09-13 |  |  |  |  |  |
| A2090 |  | TRANSPORTE DE MATERIAL GRANULAR PARA DISTANCIAS <1KM |  | 8d | 2025-08-21 | 2025-08-28 | A1890 | -1d | 0d | Costos [57801.2 h] | 57,801.21 |
| A2100 |  | TRANSPORTE DE MATERIAL GRANULAR PARA DISTANCIAS >1KM |  | 8d | 2025-08-21 | 2025-08-28 | A2090 SS | -1d | 0d | Costos [171329 h] | 171,329.24 |
| A2110 |  | TRANSPORTE DE ROCA PARA DISTANCIAS <1KM |  | 6d | 2025-08-29 | 2025-09-03 | A2100 | -1d | 0d | Costos [8325 h] | 8,325 |
| A2120 |  | TRANSPORTE DE ROCA PARA DISTANCIAS >1KM |  | 6d | 2025-08-29 | 2025-09-03 | A2110 SS | -1d | 0d | Costos [55691.7 h] | 55,691.72 |
| A2130 |  | TRANSPORTE DE MATERIAL EXCEDENTE PARA DISTANCIAS <1KM |  | 10d | 2025-09-04 | 2025-09-13 | A2120 | -1d | 0d | Costos [37807.4 h] | 37,807.36 |
| A2140 |  | TRANSPORTE DE MATERIAL EXCEDENTE PARA DISTANCIAS >1KM |  | 10d | 2025-09-04 | 2025-09-13 | A2130 SS | -1d | 0d | Costos [94761.9 h] | 94,761.91 |
|  | 1 | **IMPACTO AMBIENTAL** |  |  | 2025-07-26 | 2025-10-10 |  |  |  |  |  |
|  | 1 | **TRABAJOS DE CIERRE** |  |  | 2025-07-26 | 2025-10-10 |  |  |  |  |  |
| A2150 |  | ACONDICIONAMIENTO DE DEPOSITOS DE MATERIALES EXCEDENTES (DME) |  | 3d | 2025-07-26 | 2025-07-28 | A1790 | 43d | 44d | Costos [42547.1 h] | 42,547.1 |
| A2160 |  | SEGURIDAD Y SALUD OCUPACIONAL | level of effort | 73d | 2025-07-30 | 2025-10-10 | A1830 | -1d | 0d | Costos [41380.6 h] | 41,380.63 |
